# Sťahovanie Jesennej 5 - Technicom

Schedule from GanttProject, 2014-06-09 to 2014-07-16.
UPJŠ

## Calendars

- Project calendar: Mon-Fri working; Sat-Sun off.

## Resources

| Resource | Group |
| --- | --- |
| Maliar 1 | pracovník |
| Maliar 2 | pracovník |
| Maliar 3 | pracovník |
| Stolár 1 | pracovník |
| Stolár 2 | pracovník |
| Vodár 1 | pracovník |
| Elektrikár 1 | pracovník |
| Elektrikár 2 | pracovník |
| Elektrikár 3 | pracovník |
| Andrejko | pracovník |
| Hvizdoš | pracovník |
| Dvorný | pracovník |
| Upratovačka 1 | pracovník |
| Upratovačka 2 | pracovník |
| HUMA-LAB APEKO - Firma na presun rádioaktívnych látok |  |
| Firma na sťahovanie |  |
| Elektrikárska firma |  |

## Schedule

| ID | WBS | Task | Type | Duration | Start | Finish | Predecessors | Resources |
| --- | --- | --- | --- | --- | --- | --- | --- | --- |
| 1 | 1 | Ukončenie VO na stavby | milestone | 0d | 2014-06-09 | 2014-06-09 |  |  |
| 2 | 2 | **Premiestnenie laboratória KJSF** |  | 6d | 2014-06-09 | 2014-06-16 | 1 |  |
| 3 | 2.1 | Demolačné práce - zbúranie priečky, otočenie dverí |  | 1d | 2014-06-09 | 2014-06-09 |  |  |
| 4 | 2.2 | Montáž elektrických rozvodov - centrálny vypínač |  | 1d | 2014-06-10 | 2014-06-10 | 3 |  |
| 5 | 2.3 | Montáž internetových rozvodov - 6 až 7 PC |  | 1d | 2014-06-10 | 2014-06-10 | 3 |  |
| 6 | 2.4 | Omietky, maľovanie, podlaha, žalúzie |  | 1d | 2014-06-11 | 2014-06-11 | 4, 5 |  |
| 7 | 2.5 | Elektrické a internetové zástrčky |  | 1d | 2014-06-12 | 2014-06-12 | 6 |  |
| 8 | 2.6 | Upratanie nového labu KJSF |  | 1d | 2014-06-13 | 2014-06-13 | 7 | Upratovačka 1 |
| 9 | 2.7 | Presun laboratórneho nábytku |  | 1d | 2014-06-16 | 2014-06-16 | 8 |  |
| 10 | 2.8 | Presun malého trezora |  | 1d | 2014-06-16 | 2014-06-16 | 8 |  |
| 11 | 2.9 | Presun archívnych materiálov do archívu (bývalá malá serverovňa pri ÚINF) |  | 1d | 2014-06-09 | 2014-06-09 |  |  |
| 12 | 3 | **Vysťahovanie ÚINF** |  | 2d | 2014-06-09 | 2014-06-10 | 1 |  |
| 13 | 3.1 | Kontajner na odpad, možnosť odpisovať starý majetok |  | 1d | 2014-06-09 | 2014-06-09 |  |  |
| 14 | 3.2 | Príprava miestnosti 253 [č. dverí 32] na umiestnenie ďalšieho človeka, elektrika, pripojenie na net |  | 1d | 2014-06-09 | 2014-06-09 |  | Andrejko [30%]; Hvizdoš [30%]; Dvorný [30%] |
| 15 | 3.3 | Presun doc. Andrejkovej a nábytku z miestnosti 247 [č. dverí 37] do miestnosti 253 [č. dverí 32] (ku Kopčovi) |  | 1d | 2014-06-10 | 2014-06-10 | 14 | Stolár 1 [15%]; Stolár 2 [15%]; Vodár 1 [15%] |
| 16 | 3.4 | Uskladnenie zvyšného nábytku z miestnosti 247 [č. dverí 37] - KAM ??? |  | 1d | 2014-06-10 | 2014-06-10 | 15SS | Stolár 1 [15%]; Stolár 2 [15%]; Vodár 1 [15%] |
| 17 | 3.5 | Vysťahovanie nábytku z miestnosti 203 [č. dverí 8] pri Andrejkovi |  | 1d | 2014-06-09 | 2014-06-09 |  |  |
| 18 | 3.6 | Príprava miestnosti 203 [č. dverí 8] na umiestnenie sekretariátu ÚINF, elektrika, pripojenie na net, upratanie |  | 1d | 2014-06-09 | 2014-06-09 | 17SS | Andrejko [30%]; Hvizdoš [30%]; Dvorný [30%]; Upratovačka 1 [20%] |
| 19 | 3.7 | Presun sekretariátu ÚINF do miestnosti 203 [č. dverí 8] |  | 1d | 2014-06-10 | 2014-06-10 | 17, 18 |  |
| 20 | 3.8 | Uskladnenie zvyšného nábytku z bývalého sekretariátu ÚINF miestnosť 243 [č. dverí 72] - KAM ??? |  | 1d | 2014-06-10 | 2014-06-10 | 19SS |  |
| 21 | 3.9 | Presun ľudí z miestnosti 256 [č. dverí 38A] na CAI, do študovne, na ÚMV (Miňo, Šebej, Almarimi) |  | 1d | 2014-06-10 | 2014-06-10 |  |  |
| 22 | 3.10 | Uskladnenie nábytku z miestnosti 256 [č. dverí 38A] |  | 1d | 2014-06-10 | 2014-06-10 | 21SS |  |
| 23 | 3.11 | Príprava miestnosti 238 [č. dverí 238] na umiestnenie ďalších 3 ľudí - vysťahovanie nábytku, elektrina, internet |  | 1d | 2014-06-09 | 2014-06-09 |  |  |
| 24 | 3.12 | Presun ľudí (Horváth, Pisková, Pero) a nábytku z miestnosti 256 [č. dverí 40] do miestnosti 238 (ku Gurskému) |  | 1d | 2014-06-10 | 2014-06-10 | 23 |  |
| 25 | 3.13 | Uskladnenie nábytku z miestnosti 256 [č. dverí 40] |  | 1d | 2014-06-10 | 2014-06-10 | 24SS |  |
| 26 | 3.14 | Uskladnenie nábytku z miestnosti 244 [č. dverí 71] Semanišin - KAM ??? |  | 1d | 2014-06-09 | 2014-06-09 |  |  |

Notes:
- 12: ÚINF a CAI sa z nasledujúcich miestností vysťahuje až po dostavbe krídla budovy na Jesennej 5 - Technicom: / 238 [č. dverí 75], / 239 [č. dverí 74A], / 240 [č. dverí 74], / 245 [č.dverí 38], / 248 [č. dverí 36], / 250 [č. dverí 35], / 251-252 [č. dverí 33], / 253 [č. dverí 32].

| ID | WBS | Task | Duration | Start | Finish | Predecessors | Resources |
| --- | --- | --- | --- | --- | --- | --- | --- |
| 27 | 4 | **Rekonštrukcia miestností ÚINF** | 23d | 2014-06-12 | 2014-07-14 | 12 |  |
| 28 | 4.1 | Rekonštrukcia elektrických sietí v miestnostiach ÚINF | 7d | 2014-06-12 | 2014-06-20 |  |  |
| 29 | 4.2 | Rekonštrukcia internetových sietí v miestnostiach ÚINF | 7d | 2014-06-12 | 2014-06-20 |  |  |
| 30 | 4.3 | Montáž umývadiel do miestností 245 [č. dverí 38] a 247 [č. dverí 37] | 5d | 2014-06-12 | 2014-06-18 |  |  |
| 31 | 4.4 | Oprava omietky v miestnostiach ÚINF | 5d | 2014-06-23 | 2014-06-27 | 28, 29, 30 |  |
| 32 | 4.5 | Vymaľovanie miestností ÚINF | 3d | 2014-06-30 | 2014-07-02 | 31 |  |
| 33 | 4.6 | Montáž svetiel, vypínačov a zásuviek v miestnostiach ÚINF | 3d | 2014-07-03 | 2014-07-07 | 32 |  |
| 34 | 4.7 | Montáž plávajúcej podlahy v miestnostiach ÚINF | 5d | 2014-07-08 | 2014-07-14 | 33 |  |
| 35 | 4.8 | Montáž žalúzií v miestnostiach ÚINF | 1d | 2014-07-10 | 2014-07-10 | 34FS-3d |  |
| 36 | 4.9 | Upratanie miestností ÚINF | 3d | 2014-07-10 | 2014-07-14 | 35SS | Upratovačka 1; Upratovačka 2 |
| 37 | 5 | **Presun KJSF do bývalých priestorov ÚINF** | 2d | 2014-07-15 | 2014-07-16 | 27 |  |
| 38 | 5.1 | Vysťahovanie nábytku z miestnosti 23 - KAM ??? (Vrláková, Kravčáková, Putiš - práca na doma) | 2d | 2014-07-15 | 2014-07-16 |  |  |
| 39 | 5.2 | Presun ľudí a nábytku z KJSF z miestnosti 22 do miestnosti 244 [č. dverí 71] (Vokál) | 2d | 2014-07-15 | 2014-07-16 |  |  |
| 40 | 5.3 | Presun ľudí a nábytku z KJSF z miestnosti z miestnosti 21 do miestnosti 247 [č. dverí 37] (Dirner, Urbán) | 2d | 2014-07-15 | 2014-07-16 |  |  |
| 41 | 5.4 | Vysťahovanie nábytku z miestnosti 20A - KAM ??? (Parnahaj, Fecková, Hostová - práca na doma) | 2d | 2014-07-15 | 2014-07-16 |  |  |
| 42 | 5.5 | Presun ľudí a nábytku z KJSF z miestnosti 10 do miestnosti na prízemí PA [bývalá tel. ústredňa] (Bombara, Martinská) | 2d | 2014-07-15 | 2014-07-16 |  |  |
| 43 | 5.6 | Presun ľudí a nábytku z KJSF z miestnosti 6 do miestnosti 6 do miestnosti 243 [č. dverí 72] (Hnatič) | 2d | 2014-07-15 | 2014-07-16 |  |  |
| 44 | 5.7 | Vysťahovanie nábytku z KJSF z miestnosti 8 a jeho uskladnenie - KAM ??? | 2d | 2014-07-15 | 2014-07-16 |  |  |
| 45 | 5.8 | Vysťahovanie nábytku zo zasadačky KJSF(miestnosť 16A) a jeho uskladnenie - KAM ??? | 2d | 2014-07-15 | 2014-07-16 |  |  |
| 46 | 5.9 | Gális, Parimucha - presun ľudí a nábytku do miestnosti č. 42 na prízemí Parku Angelinum | 1d | 2014-07-15 | 2014-07-15 |  |  |
| 47 | 6 | **Vysťahovanie ÚMV z 1. poschodia Jesennej 5** | 1d | 2014-06-09 | 2014-06-09 | 1 |  |
| 48 | 6.1 | Vysťahovanie a uskladnenie nábytku z VKM, podoťahovať skutky - KAM ??? | 1d | 2014-06-09 | 2014-06-09 |  |  |
| 49 | 6.2 | Odpojenie a uskladnenie techniky z VKM | 1d | 2014-06-09 | 2014-06-09 | 48SS |  |
| 50 | 6.3 | Presun ľudí z miestnosti 109 [1. poschodie, Jesenná] - Roman Soták vie kam (Furcoňová, Hubeňáková) | 1d | 2014-06-09 | 2014-06-09 |  |  |
| 51 | 6.4 | Uskladnenie nábytku z miestnosti 109 [1. poschodie, Jesenná] - KAM ??? | 1d | 2014-06-09 | 2014-06-09 | 50SS |  |
| 52 | 6.5 | Presun ľudí z miestnosti 108 [1. poschodie, Jesenná] Roman Soták vie kam (Kubíková, Široczki) | 1d | 2014-06-09 | 2014-06-09 |  |  |
| 53 | 6.6 | Uskladnenie nábytku z miestnosti 108 [1. poschodie, Jesenná] - KAM ??? | 1d | 2014-06-09 | 2014-06-09 | 52SS |  |
| 54 | 6.7 | Presun zariadení zo serverovne na 1. poschodí Jesennej 5 do starej serverovne v Parku Angelinum | 1d | 2014-06-09 | 2014-06-09 |  | Andrejko; Hvizdoš; Dvorný |
| 55 | 6.8 | Preloženie klimatizácie zo serverovne na 1. poschodí Jesennej 5 do starej serverovne | 1d | 2014-06-09 | 2014-06-09 | 54SS |  |
| 56 | 6.9 | Presun Madarasa a Fabriciho - Roman Soták vie kam | 1d | 2014-06-09 | 2014-06-09 |  |  |

Notes:
- 45: Zasadačka KJSF nebude počas rekonštrukcie k dispozícii. / Zasadačka sa spojazdní po dostavbe krídla Jesennej 5 - Technicom a vysťahovaní ľudí z miestnosti 238, č. dverí 75 (Gurský, Novotný, Vaško, Vereščák).
- 49: Rasťo Adámek
- 54: servery: KJSF, Dirner, Černák, EVO

| ID | WBS | Task | Duration | Start | Finish | Predecessors | Resources |
| --- | --- | --- | --- | --- | --- | --- | --- |
| 57 | 7 | **Vysťahovanie ÚINF z 2. poschodia Jesennej 5** | 2d | 2014-06-09 | 2014-06-10 | 1 |  |
| 58 | 7.1 | Odpojenie a uskladnenie techniky z P6 | 1d | 2014-06-09 | 2014-06-09 |  | Andrejko; Hvizdoš; Dvorný |
| 59 | 7.2 | Demontáž, vysťahovanie a uskladnenie nábytku z P6 - KAM ??? | 1d | 2014-06-10 | 2014-06-10 | 51, 58 |  |
| 60 | 7.3 | Presun ľudí a nábytku z miestnosti 210 - k doktorandom na ÚFV, prof. Bobák ??? (Studenovský, Szabari) | 1d | 2014-06-09 | 2014-06-09 |  |  |
| 61 | 7.4 | Presun ľudí a nábytku z miestnosti 211 - KAM ??? (Gallová, Torok) | 1d | 2014-06-09 | 2014-06-09 |  |  |
| 62 | 7.5 | Presun doktorandov z miestnosti 209A [2. poschodie, Jesenná] do študovne | 1d | 2014-06-09 | 2014-06-09 |  |  |
| 63 | 7.6 | Uskladnenie nábytku z miestnosti 209A [2. poschodie, Jesenná] - KAM ??? | 1d | 2014-06-09 | 2014-06-09 | 62SS |  |
| 64 | 7.7 | Vysťahovanie nábytku a počítačov z učebne P07 - stoly do P4, a PC do skladu CAI (Hvizdoš) | 1d | 2014-06-09 | 2014-06-09 |  | Stolár 2 [20%]; Andrejko; Hvizdoš; Dvorný |
| 65 | 7.8 | Odpojenie a presťahovanie racku ÚINF | 1d | 2014-06-09 | 2014-06-09 |  |  |
| 66 | 8 | **Vysťahovanie prízemia Jesennej 5** | 3d | 2014-06-09 | 2014-06-11 | 1 |  |
| 67 | 8.1 | **Presun EVO tímu** | 3d | 2014-06-09 | 2014-06-11 |  |  |
| 68 | 8.1.1 | Vysťahovanie stolov a stoličiek z malej jedálne do bufetu | 1d | 2014-06-09 | 2014-06-09 |  |  |
| 69 | 8.1.2 | Príprava malej jedálne - el. rozvody, internet, žalúzie, upratanie | 1d | 2014-06-10 | 2014-06-10 | 68 |  |
| 70 | 8.1.3 | Presun ľudí a nábytku z miestnosti 16 [prízemie, Jesenná] do bývalej malej jedálne | 1d | 2014-06-11 | 2014-06-11 | 69 |  |
| 71 | 8.2 | **Presun Černákovcov - práca na doma** | 1d | 2014-06-10 | 2014-06-10 |  |  |
| 72 | 8.2.1 | Vysťahovanie nábytku z miestnosti 15 [prízemie Jesenná] (Černákovci) - KAM ??? | 1d | 2014-06-10 | 2014-06-10 |  |  |
| 73 | 8.3 | **Vysťahovanie biofyzikov** | 1d | 2014-06-09 | 2014-06-09 |  |  |
| 74 | 8.3.1 | Presun nábytku a vysťahovanie - Bánó | 1d | 2014-06-09 | 2014-06-09 |  |  |
| 75 | 8.3.2 | Presun nábytku a vysťahovanie - Jancura, Fabriciová | 1d | 2014-06-09 | 2014-06-09 |  |  |
| 76 | 9 | Odpojenie a presťahovanie racku KJSF | 1d | 2014-06-09 | 2014-06-09 |  |  |
| 77 | 10 | **Presun SKALTA** | 1d | 2014-06-09 | 2014-06-09 | 1 |  |
| 78 | 10.1 | Presun / uskladnenie zariadenia na streche - KAM ??? (Bombara, Dirner) | 1d | 2014-06-09 | 2014-06-09 |  |  |
| 79 | 10.2 | Presun prístrojov z miestnosti 108 [1. poschodie, Jesenná] - KAM ??? (Bombara, Dirner) | 1d | 2014-06-09 | 2014-06-09 |  |  |

Notes:
- 64: PC učebňa P07 nebude počas trvania stavby k dispozícii.
